# OB-01 - stampbeton fundering

Schedule from MS Project, 2003-01-12 to 2003-01-26, status date 2003-01-08.
BAM Nelissen Van Egteren

## Calendars

- ALLEEN WERKDAGEN: Mon-Fri 08:30-12:30, 13:00-17:00; Sat-Sun off. Exceptions (off unless hours are given): 2003-01-11 to 2003-01-12 08:30-12:30, 13:00-17:00, 2003-01-18 to 2003-01-19 08:30-12:30, 13:00-17:00, 2003-01-25 to 2003-01-26 08:30-12:30, 13:00-17:00.

## Schedule

| ID | WBS | Task | Type | Duration | Start | Finish | Predecessors | Total slack |
| --- | --- | --- | --- | --- | --- | --- | --- | --- |
| 1 | 1 | **ONDERBOUWFASE** |  | 15d | 2003-01-12 | 2003-01-26 |  | 0d |
| 2 | 1.1 | balkbekisting stellen |  | 5d | 2003-01-12 | 2003-01-16 |  | 0d |
| 3 | 1.2 | stampbeton fund.balken storten |  | 4d | 2003-01-13 | 2003-01-16 | 2SS+1d | 0d |
| 4 | 1.3 | funderingsbalken ontkisten |  | 4d | 2003-01-15 | 2003-01-18 | 3SS+2d | 0d |
| 5 | 1.4 | leidingen monteren onder vloer |  | 4d | 2003-01-18 | 2003-01-21 | 4SS+3d | 0d |
| 6 | 1.5 | systeemvloer leggen |  | 2d | 2003-01-21 | 2003-01-22 | 5SS+3d | 0d |
| 7 | 1.6 | randkist+sparingkist vloer |  | 2d | 2003-01-23 | 2003-01-24 | 6SS+2d | 0d |
| 8 | 1.7 | beganegrond vloer afstorten |  | 1d | 2003-01-25 | 2003-01-25 | 7SS+2d | 0d |
| 9 | 1.8 | maatvoeren voor bovenbouw |  | 1d | 2003-01-26 | 2003-01-26 | 8SS+1d | 0d |
| 10 | 1.9 | start bovenbouw | milestone | 0d | 2003-01-26 | 2003-01-26 | 9SS+1d | 0d |
